# Cronograma de Obra Subproyecto A4

Schedule from MS Project, 2022-12-18 to 2023-05-15.

## Calendars

- Subproyecto A4: Mon-Sun 09:00-13:00, 15:00-19:00.

## Schedule

| ID | WBS | Task | Type | Duration | Start | Finish | Predecessors | Total slack | Free slack |
| --- | --- | --- | --- | --- | --- | --- | --- | --- | --- |
| 1 | 1 | **SUBPROYECTO A4** |  | 149d | 2022-12-18 | 2023-05-15 |  | 0d |  |
| 2 | 1.1 | INICIO DE PROYECTO | milestone, manual | 0d | 2022-12-18 | 2022-12-18 |  |  |  |
| 3 | 1.2 | **PAMPA DEL TORO** |  | 43d | 2023-02-16 | 2023-03-30 |  | 21d |  |
| 4 | 1.2.1 | **MEJORAMIENTO DE VIAS EXISTENTES** |  | 15d | 2023-02-16 | 2023-03-02 |  | 21d |  |
| 5 | 1.2.1.1 | **MOVIMIENTO DE TIERRAS** |  | 12d | 2023-02-16 | 2023-02-27 |  | 21d |  |
| 6 | 1.2.1.1.1 | ROCE Y LIMPIEZA DE MALEZA |  | 1d | 2023-02-16 | 2023-02-16 | 74 | 55d | 0d |
| 7 | 1.2.1.1.2 | MEJORAMIENTO DE VIAS EXISTENTES |  | 11d | 2023-02-17 | 2023-02-27 | 6 | 55d | 0d |
| 8 | 1.2.1.2 | **REPOSICIÓN DE ESTRUCTURAS** |  | 10d | 2023-02-18 | 2023-02-27 |  | 54d |  |
| 9 | 1.2.1.2.1 | DEMOLICIÓN DE ESTRUCTURAS EXISTENTES |  | 1d | 2023-02-18 | 2023-02-18 | 7SS+1d | 86d |  |
| 10 | 1.2.1.2.2 | REPOSICIÓN DE PASE DE AGUA TUBERÍA HDPE Ø=36" |  | 4d | 2023-02-19 | 2023-02-22 | 7SS+2d | 74d | 0d |
| 11 | 1.2.1.2.3 | REPOSICIÓN DE PASE DE AGUA TUBERÍA HDPE Ø=24" |  | 3d | 2023-02-23 | 2023-02-25 | 10 | 74d | 0d |
| 12 | 1.2.1.2.4 | SUMINISTRO Y MONTAJE DE LOSAS DE C°A° 1.6mx1.0mx0.20m EN PASE DE AGUA |  | 2d | 2023-02-26 | 2023-02-27 | 11 | 74d | 0d |
| 13 | 1.2.1.3 | **ESTRUCTURAS DE CONCRETO** |  | 3d | 2023-02-28 | 2023-03-02 |  | 74d |  |
| 14 | 1.2.1.3.1 | CONCRETO 175 Kg/Cm2 |  | 1d | 2023-03-02 | 2023-03-02 | 15 | 74d |  |
| 15 | 1.2.1.3.2 | ENCOFRADO Y DESENCOFRADO NORMAL |  | 2d | 2023-02-28 | 2023-03-01 | 12 | 74d | 0d |
| 16 | 1.2.2 | **DIQUES Y PROTECCIÓN DE CAUCE CON ENROCADO** |  | 23d | 2023-03-07 | 2023-03-29 |  | 25d |  |
| 17 | 1.2.2.1 | **DIQUE DE TIERRA COMPACTADA A4-PT-D-05** |  | 16d | 2023-03-07 | 2023-03-22 |  | 25d |  |
| 18 | 1.2.2.1.1 | DESBROCE Y LIMPIEZA EN ZONA NO BOSCOSA |  | 1d | 2023-03-07 | 2023-03-07 | 51 | 59d | 0d |
| 19 | 1.2.2.1.2 | EXCAVACIÓN EN TERRENO NATURAL CON EQUIPO |  | 2d | 2023-03-08 | 2023-03-09 | 18 | 59d | 0d |
| 20 | 1.2.2.1.3 | PERFILADO Y COMPACTACIÓN EN ZONA DE CORTE |  | 2d | 2023-03-09 | 2023-03-10 | 19SS+1d | 59d | 4d |
| 21 | 1.2.2.1.4 | CONFORMACIÓN DE CUERPO DE DIQUE |  | 4d | 2023-03-10 | 2023-03-13 | 19 | 60d | 0d |
| 22 | 1.2.2.1.5 | CONFORMACIÓN DE MATERIAL GRANULAR EN CORONA DE DIQUE |  | 1d | 2023-03-22 | 2023-03-22 | 24 | 52d | 0d |
| 23 | 1.2.2.1.6 | GEOTEXTIL NO TEJIDO 400 G/M2, INC. COLOCACIÓN |  | 6d | 2023-03-11 | 2023-03-16 | 21SS+1d | 60d |  |
| 24 | 1.2.2.1.7 | COLOCACION Y ACOMODO DE ROCA EN UÑA DE DIQUE |  | 7d | 2023-03-15 | 2023-03-21 | 20, 52 | 55d | 0d |
| 25 | 1.2.2.1.8 | COLOCACION Y ACOMODO DE ROCA EN TALUD DE DIQUE |  | 7d | 2023-03-15 | 2023-03-21 | 24SS | 55d |  |

| ID | WBS | Task | Duration | Start | Finish | Predecessors | Total slack | Free slack |
| --- | --- | --- | --- | --- | --- | --- | --- | --- |
| 26 | 1.2.2.2 | **DIQUE DE TIERRA COMPACTADA A4-PT-D-04** | 13d | 2023-03-11 | 2023-03-23 |  | 32d |  |
| 27 | 1.2.2.2.1 | DESBROCE Y LIMPIEZA EN ZONA NO BOSCOSA | 1d | 2023-03-11 | 2023-03-11 | 20 | 56d | 0d |
| 28 | 1.2.2.2.2 | EXCAVACIÓN EN TERRENO NATURAL CON EQUIPO | 3d | 2023-03-12 | 2023-03-14 | 27 | 56d | 0d |
| 29 | 1.2.2.2.3 | PERFILADO Y COMPACTACIÓN EN ZONA DE CORTE | 2d | 2023-03-14 | 2023-03-15 | 28SS+2d | 56d | 0d |
| 30 | 1.2.2.2.4 | CONFORMACIÓN DE CUERPO DE DIQUE | 1d | 2023-03-14 | 2023-03-14 | 21 | 62d |  |
| 31 | 1.2.2.2.5 | CONFORMACIÓN DE MATERIAL GRANULAR EN CORONA DE DIQUE | 1d | 2023-03-23 | 2023-03-23 | 22 | 52d | 0d |
| 32 | 1.2.2.2.6 | GEOTEXTIL NO TEJIDO 400 G/M2, INC. COLOCACIÓN | 2d | 2023-03-17 | 2023-03-18 | 23 | 52d | 0d |
| 33 | 1.2.2.2.7 | COLOCACION Y ACOMODO DE ROCA EN UÑA DE DIQUE | 2d | 2023-03-22 | 2023-03-23 | 24 | 46d | 0d |
| 34 | 1.2.2.2.8 | COLOCACION Y ACOMODO DE ROCA EN TALUD DE DIQUE | 2d | 2023-03-22 | 2023-03-23 | 33SS | 53d |  |
| 35 | 1.2.2.3 | **PROTECCION DE TALUDES** | 14d | 2023-03-16 | 2023-03-29 |  | 29d |  |
| 36 | 1.2.2.3.1 | DESBROCE Y LIMPIEZA EN ZONA NO BOSCOSA | 1d | 2023-03-16 | 2023-03-16 | 29 | 56d | 0d |
| 37 | 1.2.2.3.2 | EXCAVACIÓN EN TERRENO NATURAL CON EQUIPO | 2d | 2023-03-17 | 2023-03-18 | 36 | 56d | 0d |
| 38 | 1.2.2.3.3 | PERFILADO Y COMPACTACIÓN EN ZONA DE CORTE | 3d | 2023-03-18 | 2023-03-20 | 37SS+1d | 56d |  |
| 39 | 1.2.2.3.4 | RELLENO ESTRUCTURAL CON MATERIAL PROPIO | 1d | 2023-03-24 | 2023-03-24 | 31 | 52d |  |
| 40 | 1.2.2.3.5 | GEOTEXTIL NO TEJIDO 400 G/M2, INC. COLOCACIÓN | 6d | 2023-03-19 | 2023-03-24 | 32 | 52d |  |
| 41 | 1.2.2.3.6 | COLOCACION Y ACOMODO DE ROCA EN UÑA DE DIQUE | 6d | 2023-03-24 | 2023-03-29 | 33 | 46d | 0d |
| 42 | 1.2.2.3.7 | COLOCACION Y ACOMODO DE ROCA EN TALUD DE DIQUE | 6d | 2023-03-24 | 2023-03-29 | 41SS | 47d |  |
| 43 | 1.2.3 | **REPOSICIÓN DE CAMINO DE ACCESO A4-RC-1** | 4d | 2023-02-28 | 2023-03-03 |  | 21d |  |
| 44 | 1.2.3.1 | DESBROCE Y LIMPIEZA EN ZONA NO BOSCOSA | 1d | 2023-02-28 | 2023-02-28 | 7 | 55d | 0d |
| 45 | 1.2.3.2 | EXCAVACIÓN EN MATERIAL SUELTO CON EQUIPO | 1d | 2023-03-01 | 2023-03-01 | 44 | 55d | 0d |
| 46 | 1.2.3.3 | PERFILADO Y COMPACTACIÓN EN ZONA DE CORTE | 1d | 2023-03-02 | 2023-03-02 | 45 | 55d | 0d |
| 47 | 1.2.3.4 | MATERIAL AFIRMADO e=25 cm | 1d | 2023-03-03 | 2023-03-03 | 46 | 73d |  |
| 48 | 1.2.4 | **PROTECCION DEL CAUCE CON ENROCADO** | 12d | 2023-03-03 | 2023-03-14 |  | 21d |  |
| 49 | 1.2.4.1 | DESBROCE Y LIMPIEZA EN ZONA NO BOSCOSA | 1d | 2023-03-03 | 2023-03-03 | 46 | 55d | 0d |
| 50 | 1.2.4.2 | EXCAVACIÓN EN MATERIAL SUELTO CON EQUIPO | 1d | 2023-03-04 | 2023-03-04 | 49 | 55d | 0d |
| 51 | 1.2.4.3 | PERFILADO Y COMPACTACIÓN CON EQUIPO DE FONDO DE EXCAVACIÓN | 2d | 2023-03-05 | 2023-03-06 | 50 | 55d | 0d |
| 52 | 1.2.4.4 | COLOCACION DE ROCA EN CAUCE | 8d | 2023-03-07 | 2023-03-14 | 51 | 55d | 0d |

| ID | WBS | Task | Duration | Start | Finish | Predecessors | Total slack | Free slack |
| --- | --- | --- | --- | --- | --- | --- | --- | --- |
| 53 | 1.2.5 | **TRANSPORTE DE MATERIAL** | 42d | 2023-02-16 | 2023-03-29 |  | 47d |  |
| 54 | 1.2.5.1 | TRANPORTE DE MATERIAL GRANULAR PARA DISTANCIAS <1KM | 33d | 2023-02-19 | 2023-03-23 | 10SS | 53d | 0d |
| 55 | 1.2.5.2 | TRANPORTE DE MATERIAL GRANULAR PARA DISTANCIAS >1KM | 33d | 2023-02-19 | 2023-03-23 | 54SS | 53d |  |
| 56 | 1.2.5.3 | TRANPORTE DE ROCA PARA DISTANCIAS <1KM | 23d | 2023-03-07 | 2023-03-29 | 52SS | 47d | 0d |
| 57 | 1.2.5.4 | TRANPORTE DE ROCA PARA DISTANCIAS >1KM | 23d | 2023-03-07 | 2023-03-29 | 56SS | 47d |  |
| 58 | 1.2.5.5 | TRANPORTE DE MATERIAL EXCEDENTE PARA DISTANCIAS <1KM | 37d | 2023-02-16 | 2023-03-24 | 6SS | 52d | 0d |
| 59 | 1.2.5.6 | TRANPORTE DE MATERIAL EXCEDENTE PARA DISTANCIAS >1KM | 37d | 2023-02-16 | 2023-03-24 | 58SS | 52d |  |
| 60 | 1.2.6 | **PROGRAMA DE CIERRE DE OBRA** | 43d | 2023-02-16 | 2023-03-30 |  | 46d |  |
| 61 | 1.2.6.1 | ACONDICIONAMIENTO DE DEPOSITOS DE MATERIALES EXCEDENTES (DME) | 37d | 2023-02-16 | 2023-03-24 | 58SS | 52d |  |
| 62 | 1.2.6.2 | RESTAURACIÓN DE ÁREAS DE INSTALACIONES PROVISIONALES | 1d | 2023-03-30 | 2023-03-30 | 41 | 46d |  |
| 63 | 1.3 | **SUBPROYECTO A4** | 149d | 2022-12-18 | 2023-05-15 |  | 0d |  |
| 64 | 1.3.1 | **OBRAS PRELIMINARES** | 145d | 2022-12-22 | 2023-05-15 |  | 0d |  |
| 65 | 1.3.1.1 | CARTEL DE IDENTIFICACIÓN OBRA 4.80 x 3.60 m. | 2d | 2022-12-27 | 2022-12-28 | 69SS+9d | 138d |  |
| 66 | 1.3.1.2 | INSTALACIONES PROVISIONALES PARA LA OBRA | 145d | 2022-12-22 | 2023-05-15 | 69SS+4d | 0d |  |
| 67 | 1.3.1.3 | MANTENIMIENTO DE TRÁNSITO Y SEGURIDAD VIAL | 140d | 2022-12-27 | 2023-05-15 | 69SS+9d | 0d |  |
| 68 | 1.3.2 | **TRABAJOS PRELIMINARES** | 149d | 2022-12-18 | 2023-05-15 |  | 0d |  |
| 69 | 1.3.2.1 | MOVILIZACION Y DESMOVILIZACION DE EQUIPOS | 149d | 2022-12-18 | 2023-05-15 | 2 | 0d |  |
| 70 | 1.3.2.2 | TOPOGRAFÍA Y GEORREFERENCIACIÓN | 145d | 2022-12-22 | 2023-05-15 | 69SS+4d | 0d |  |
| 71 | 1.3.3 | **MEJORAMIENTO DE VÍAS EXISTENTES** | 51d | 2022-12-27 | 2023-02-15 |  | 0d |  |
| 72 | 1.3.3.1 | **MOVIMIENTO DE TIERRAS** | 51d | 2022-12-27 | 2023-02-15 |  | 0d |  |
| 73 | 1.3.3.1.1 | ROCE Y LIMPIEZA DE MALEZA | 2d | 2022-12-27 | 2022-12-28 | 67SS | 0d |  |
| 74 | 1.3.3.1.2 | MEJORAMIENTO DE VIAS EXISTENTES | 49d | 2022-12-29 | 2023-02-15 | 73 | 55d | 0d |
| 75 | 1.3.3.2 | **REPOSICIÓN DE ESTRUCTURAS** | 21d | 2023-01-03 | 2023-01-23 |  | 112d |  |
| 76 | 1.3.3.2.1 | DEMOLICIÓN DE ESTRUCTURAS EXISTENTES | 1d | 2023-01-03 | 2023-01-03 | 74SS+5d | 132d |  |
| 77 | 1.3.3.2.2 | REPOSICIÓN DE PASE DE AGUA TUBO HDPE Ø=24" | 3d | 2023-01-10 | 2023-01-12 | 74SS+12d | 112d | 0d |
| 78 | 1.3.3.2.3 | REPOSICIÓN DE PASE DE AGUA TUBO HDPE Ø=36" | 3d | 2023-01-19 | 2023-01-21 | 74SS+21d | 110d | 0d |
| 79 | 1.3.3.2.4 | SUMINISTRO Y MONTAJE DE PANELES DE C°A° 2.20mx1.0mx0.20m en Pase de Agua | 11d | 2023-01-13 | 2023-01-23 | 77 | 112d |  |

| ID | WBS | Task | Duration | Start | Finish | Predecessors | Total slack | Free slack |
| --- | --- | --- | --- | --- | --- | --- | --- | --- |
| 80 | 1.3.3.3 | **CABEZAL DE ENTRADA Y SALIDA** | 4d | 2023-01-22 | 2023-01-25 |  | 110d |  |
| 81 | 1.3.3.3.1 | CONCRETO 175 Kg/Ccm2 | 1d | 2023-01-25 | 2023-01-25 | 82 | 110d |  |
| 82 | 1.3.3.3.2 | ENCOFRADO Y DESENCOFRADO NORMAL | 3d | 2023-01-22 | 2023-01-24 | 78 | 110d | 0d |
| 83 | 1.3.4 | **DESCOLMATACIÓN DE CAUCE** | 128d | 2022-12-29 | 2023-05-05 |  | 0d |  |
| 84 | 1.3.4.1 | **DESBROCE Y LIMPIEZA EN ZONA NO BOSCOSA** | 128d | 2022-12-29 | 2023-05-05 |  | 10d |  |
| 85 | 1.3.4.1.1 | DESBROCE Y LIMPIEZA EN ZONA NO BOSCOSA SUBPROYECTO A4 | 128d | 2022-12-29 | 2023-05-05 | 73 | 10d |  |
| 86 | 1.3.4.2 | **DESCOLMATACIÓN EN CAUCE NATURAL** | 128d | 2022-12-29 | 2023-05-05 |  | 0d |  |
| 87 | 1.3.4.2.1 | DESCOLMATACIÓN DE CAUCE NATURAL EN RIO LACRAMARCA | 128d | 2022-12-29 | 2023-05-05 | 73 | 0d |  |
| 88 | 1.3.4.2.2 | DESCOLMATACIÓN DE CAUCE NATURAL EN BRAZO SECUNDARIO | 14d | 2023-02-09 | 2023-02-22 | 87SS+42d | 75d | 0d |
| 89 | 1.3.4.2.3 | DESCOLMATACIÓN DE CAUCE NATURAL EN QUEBRADA PAMPA DEL TORO | 7d | 2023-02-23 | 2023-03-01 | 88 | 75d |  |
| 90 | 1.3.5 | **DIQUES DE TIERRA COMPACTADA CON ENROCADO** | 132d | 2023-01-04 | 2023-05-15 |  | 0d |  |
| 91 | 1.3.5.1 | **DIQUE DE TIERRA COMPACTADA A4-D-01** | 132d | 2023-01-04 | 2023-05-15 |  | 0d |  |
| 92 | 1.3.5.1.1 | EXCAVACIÓN EN TERRENO NATURAL CON EQUIPO | 57d | 2023-01-04 | 2023-03-01 | 87SS+6d | 0d |  |
| 93 | 1.3.5.1.2 | EXCAVACIÓN EN UÑA CON EQUIPO | 53d | 2023-01-10 | 2023-03-03 | 92SS+6d | 0d |  |
| 94 | 1.3.5.1.3 | PERFILADO Y COMPACTACIÓN EN ZONA DE CORTE | 47d | 2023-01-17 | 2023-03-04 | 93SS+7d | 0d |  |
| 95 | 1.3.5.1.4 | CONFORMACIÓN DE CUERPO DE DIQUE CON MATERIAL PROPIO | 1d | 2023-03-03 | 2023-03-03 | 100 | 73d |  |
| 96 | 1.3.5.1.5 | CONFORMACIÓN DE MATERIAL GRANULAR EN CORONA DE DIQUE | 10d | 2023-05-06 | 2023-05-15 | 98FS-10d | 0d |  |
| 97 | 1.3.5.1.6 | GEOTEXTIL NO TEJIDO 400 G/M2, INC. COLOCACIÓN | 58d | 2023-01-18 | 2023-03-16 | 94SS+1d | 0d |  |
| 98 | 1.3.5.1.7 | COLOCACION Y ACOMODO DE ROCA EN UÑA DE DIQUE | 117d | 2023-01-19 | 2023-05-15 | 97SS+1d | 0d |  |
| 99 | 1.3.5.1.8 | COLOCACION Y ACOMODO DE ROCA EN TALUD DE DIQUE | 117d | 2023-01-19 | 2023-05-15 | 98SS | 0d |  |
| 100 | 1.3.5.1.9 | PREPARACIÓN DE FUNDACIÓN DE CUERPO DE DIQUE | 1d | 2023-03-02 | 2023-03-02 | 92 | 73d | 0d |
| 101 | 1.3.5.2 | **DIQUE DE TIERRA COMPACTADA A4-I-01** | 84d | 2023-02-21 | 2023-05-15 |  | 0d |  |
| 102 | 1.3.5.2.1 | EXCAVACIÓN EN TERRENO NATURAL CON EQUIPO | 19d | 2023-02-21 | 2023-03-11 | 132 | 65d |  |
| 103 | 1.3.5.2.2 | EXCAVACIÓN EN UÑA CON EQUIPO | 19d | 2023-02-23 | 2023-03-13 | 133 | 63d |  |
| 104 | 1.3.5.2.3 | PERFILADO Y COMPACTACIÓN EN ZONA DE CORTE | 19d | 2023-02-24 | 2023-03-14 | 134 | 62d |  |
| 105 | 1.3.5.2.4 | CONFORMACIÓN DE CUERPO DE DIQUE CON MATERIAL PROPIO | 1d | 2023-03-08 | 2023-03-08 | 110 | 68d |  |
| 106 | 1.3.5.2.5 | CONFORMACIÓN DE MATERIAL GRANULAR EN CORONA DE DIQUE | 4d | 2023-05-12 | 2023-05-15 | 108FS-2d | 0d |  |
| 107 | 1.3.5.2.6 | GEOTEXTIL NO TEJIDO 400 G/M2, INC. COLOCACIÓN | 24d | 2023-03-09 | 2023-04-01 | 137 | 44d |  |
| 108 | 1.3.5.2.7 | COLOCACION Y ACOMODO DE ROCA EN UÑA DE DIQUE | 50d | 2023-03-25 | 2023-05-13 | 138 | 0d |  |
| 109 | 1.3.5.2.8 | COLOCACION Y ACOMODO DE ROCA EN TALUD DE DIQUE | 50d | 2023-03-25 | 2023-05-13 | 108SS | 2d |  |
| 110 | 1.3.5.2.9 | PREPARACIÓN DE FUNDACIÓN DE CUERPO DE DIQUE | 1d | 2023-03-07 | 2023-03-07 | 135 | 68d | 0d |

| ID | WBS | Task | Duration | Start | Finish | Predecessors | Total slack | Free slack |
| --- | --- | --- | --- | --- | --- | --- | --- | --- |
| 111 | 1.3.5.3 | **DIQUE DE TIERRA COMPACTADA A4-I-02** | 71d | 2023-01-04 | 2023-03-15 |  | 0d |  |
| 112 | 1.3.5.3.1 | EXCAVACIÓN EN TERRENO NATURAL CON EQUIPO | 38d | 2023-01-04 | 2023-02-10 | 92SS | 0d |  |
| 113 | 1.3.5.3.2 | EXCAVACIÓN EN UÑA CON EQUIPO | 34d | 2023-01-09 | 2023-02-11 | 112SS+5d | 0d |  |
| 114 | 1.3.5.3.3 | PERFILADO Y COMPACTACIÓN EN ZONA DE CORTE | 34d | 2023-01-11 | 2023-02-13 | 113SS+2d | 0d |  |
| 115 | 1.3.5.3.4 | CONFORMACIÓN DE CUERPO DE DIQUE CON MATERIAL PROPIO | 1d | 2023-02-12 | 2023-02-12 | 120 | 0d |  |
| 116 | 1.3.5.3.5 | CONFORMACIÓN DE MATERIAL GRANULAR EN CORONA DE DIQUE | 6d | 2023-03-10 | 2023-03-15 | 118FS-4d | 61d |  |
| 117 | 1.3.5.3.6 | GEOTEXTIL NO TEJIDO 400 G/M2, INC. COLOCACIÓN | 34d | 2023-01-12 | 2023-02-14 | 114SS+1d | 90d |  |
| 118 | 1.3.5.3.7 | COLOCACION Y ACOMODO DE ROCA EN UÑA DE DIQUE | 60d | 2023-01-13 | 2023-03-13 | 114SS+2d | 0d |  |
| 119 | 1.3.5.3.8 | COLOCACION Y ACOMODO DE ROCA EN TALUD DE DIQUE | 60d | 2023-01-13 | 2023-03-13 | 118SS | 63d |  |
| 120 | 1.3.5.3.9 | PREPARACIÓN DE FUNDACIÓN DE CUERPO DE DIQUE | 1d | 2023-02-11 | 2023-02-11 | 112 | 0d |  |
| 121 | 1.3.5.4 | **DIQUE DE TIERRA COMPACTADA A4-BS-D-01** | 79d | 2023-02-12 | 2023-05-01 |  | 14d |  |
| 122 | 1.3.5.4.1 | EXCAVACIÓN EN TERRENO NATURAL CON EQUIPO | 15d | 2023-02-14 | 2023-02-28 | 114 | 73d | 0d |
| 123 | 1.3.5.4.2 | EXCAVACIÓN EN UÑA CON EQUIPO | 13d | 2023-02-17 | 2023-03-01 | 122SS+3d | 73d | 0d |
| 124 | 1.3.5.4.3 | PERFILADO Y COMPACTACIÓN EN ZONA DE CORTE | 12d | 2023-02-20 | 2023-03-03 | 123SS+3d | 73d |  |
| 125 | 1.3.5.4.4 | CONFORMACIÓN DE CUERPO DE DIQUE CON MATERIAL PROPIO | 17d | 2023-02-14 | 2023-03-02 | 130 | 74d |  |
| 126 | 1.3.5.4.5 | CONFORMACIÓN DE MATERIAL GRANULAR EN CORONA DE DIQUE | 6d | 2023-04-26 | 2023-05-01 | 129FS-4d | 14d |  |
| 127 | 1.3.5.4.6 | GEOTEXTIL NO TEJIDO 400 G/M2, INC. COLOCACIÓN | 27d | 2023-02-15 | 2023-03-13 | 117 | 63d |  |
| 128 | 1.3.5.4.7 | COLOCACION Y ACOMODO DE ROCA EN UÑA DE DIQUE | 47d | 2023-03-14 | 2023-04-29 | 118 | 14d | 0d |
| 129 | 1.3.5.4.8 | COLOCACION Y ACOMODO DE ROCA EN TALUD DE DIQUE | 47d | 2023-03-14 | 2023-04-29 | 128SS | 14d | 0d |
| 130 | 1.3.5.4.9 | PREPARACIÓN DE FUNDACIÓN DE CUERPO DE DIQUE | 2d | 2023-02-12 | 2023-02-13 | 120 | 74d | 0d |
| 131 | 1.3.5.5 | **DIQUE DE TIERRA COMPACTADA A4-BS-I-01** | 43d | 2023-02-11 | 2023-03-25 |  | 0d |  |
| 132 | 1.3.5.5.1 | EXCAVACIÓN EN TERRENO NATURAL CON EQUIPO | 10d | 2023-02-11 | 2023-02-20 | 112 | 0d |  |
| 133 | 1.3.5.5.2 | EXCAVACIÓN EN UÑA CON EQUIPO | 9d | 2023-02-14 | 2023-02-22 | 132SS+3d | 0d |  |
| 134 | 1.3.5.5.3 | PERFILADO Y COMPACTACIÓN EN ZONA DE CORTE | 8d | 2023-02-16 | 2023-02-23 | 133SS+2d | 0d |  |
| 135 | 1.3.5.5.4 | CONFORMACIÓN DE CUERPO DE DIQUE CON MATERIAL PROPIO | 12d | 2023-02-23 | 2023-03-06 | 140 | 70d |  |
| 136 | 1.3.5.5.5 | CONFORMACIÓN DE MATERIAL GRANULAR EN CORONA DE DIQUE | 3d | 2023-03-23 | 2023-03-25 | 138FS-2d | 51d |  |
| 137 | 1.3.5.5.6 | GEOTEXTIL NO TEJIDO 400 G/M2, INC. COLOCACIÓN | 19d | 2023-02-18 | 2023-03-08 | 134SS+2d | 0d |  |
| 138 | 1.3.5.5.7 | COLOCACION Y ACOMODO DE ROCA EN UÑA DE DIQUE | 32d | 2023-02-21 | 2023-03-24 | 137SS+3d | 0d |  |
| 139 | 1.3.5.5.8 | COLOCACION Y ACOMODO DE ROCA EN TALUD DE DIQUE | 32d | 2023-02-21 | 2023-03-24 | 138SS | 52d |  |
| 140 | 1.3.5.5.9 | PREPARACIÓN DE FUNDACIÓN DE CUERPO DE DIQUE | 2d | 2023-02-21 | 2023-02-22 | 132 | 70d | 0d |

| ID | WBS | Task | Duration | Start | Finish | Predecessors | Total slack | Free slack |
| --- | --- | --- | --- | --- | --- | --- | --- | --- |
| 141 | 1.3.5.6 | **DIQUE DE TIERRA COMPACTADA A4-D-00** | 17d | 2023-03-21 | 2023-04-06 |  | 30d |  |
| 142 | 1.3.5.6.1 | EXCAVACIÓN EN TERRENO NATURAL CON EQUIPO | 2d | 2023-03-21 | 2023-03-22 | 38 | 40d | 0d |
| 143 | 1.3.5.6.2 | EXCAVACIÓN EN UÑA CON EQUIPO | 2d | 2023-03-22 | 2023-03-23 | 142SS+1d | 40d | 0d |
| 144 | 1.3.5.6.3 | PERFILADO Y COMPACTACIÓN EN ZONA DE CORTE | 1d | 2023-03-23 | 2023-03-23 | 143SS+1d | 40d | 0d |
| 145 | 1.3.5.6.4 | CONFORMACIÓN DE CUERPO DE DIQUE CON2 MATERIAL PROPIO | 2d | 2023-03-26 | 2023-03-27 | 150 | 47d | 0d |
| 146 | 1.3.5.6.5 | CONFORMACIÓN DE MATERIAL GRANULAR EN CORONA DE DIQUE | 1d | 2023-04-06 | 2023-04-06 | 148 | 39d |  |
| 147 | 1.3.5.6.6 | GEOTEXTIL NO TEJIDO 400 G/M2, INC. COLOCACIÓN | 6d | 2023-03-24 | 2023-03-29 | 144 | 40d | 0d |
| 148 | 1.3.5.6.7 | COLOCACION Y ACOMODO DE ROCA EN UÑA DE DIQUE | 7d | 2023-03-30 | 2023-04-05 | 41 | 27d | 0d |
| 149 | 1.3.5.6.8 | COLOCACION Y ACOMODO DE ROCA EN TALUD DE DIQUE | 7d | 2023-03-30 | 2023-04-05 | 148SS | 40d |  |
| 150 | 1.3.5.6.9 | PREPARACIÓN DE FUNDACIÓN DE CUERPO DE DIQUE | 1d | 2023-03-25 | 2023-03-25 | 39 | 47d | 0d |
| 151 | 1.3.5.7 | **DIQUE DE TIERRA COMPACTADA A4-I-00** | 21d | 2023-03-24 | 2023-04-13 |  | 32d |  |
| 152 | 1.3.5.7.1 | EXCAVACIÓN EN TERRENO NATURAL CON EQUIPO | 2d | 2023-03-24 | 2023-03-25 | 144 | 48d | 0d |
| 153 | 1.3.5.7.2 | EXCAVACIÓN EN UÑA CON EQUIPO | 3d | 2023-03-25 | 2023-03-27 | 152SS+1d | 48d | 0d |
| 154 | 1.3.5.7.3 | PERFILADO Y COMPACTACIÓN EN ZONA DE CORTE | 2d | 2023-03-27 | 2023-03-28 | 153SS+2d | 48d |  |
| 155 | 1.3.5.7.4 | CONFORMACIÓN DE CUERPO DE DIQUE CON MATERIAL PROPIO | 1d | 2023-03-29 | 2023-03-29 | 160 | 47d |  |
| 156 | 1.3.5.7.5 | CONFORMACIÓN DE MATERIAL GRANULAR EN CORONA DE DIQUE | 1d | 2023-04-13 | 2023-04-13 | 158 | 27d | 0d |
| 157 | 1.3.5.7.6 | GEOTEXTIL NO TEJIDO 400 G/M2, INC. COLOCACIÓN | 7d | 2023-03-30 | 2023-04-05 | 147 | 40d |  |
| 158 | 1.3.5.7.7 | COLOCACION Y ACOMODO DE ROCA EN UÑA DE DIQUE | 7d | 2023-04-06 | 2023-04-12 | 148 | 27d | 0d |
| 159 | 1.3.5.7.8 | COLOCACION Y ACOMODO DE ROCA EN TALUD DE DIQUE | 7d | 2023-04-06 | 2023-04-12 | 158SS | 33d |  |
| 160 | 1.3.5.7.9 | PREPARACIÓN DE FUNDACIÓN DE CUERPO DE DIQUE | 1d | 2023-03-28 | 2023-03-28 | 145 | 47d | 0d |
| 161 | 1.3.6 | **RAMPAS** | 6d | 2023-04-13 | 2023-04-18 |  | 22d |  |
| 162 | 1.3.6.1 | EXCAVACIÓN EN TERRENO NATURAL CON EQUIPO | 1d | 2023-04-13 | 2023-04-13 | 158 | 32d |  |
| 163 | 1.3.6.2 | CONFORMACIÓN DE CUERPO DE RAMPA CON MATERIAL PROPIO | 4d | 2023-04-14 | 2023-04-17 | 156 | 27d | 0d |
| 164 | 1.3.6.3 | CONFORMACIÓN DE MATERIAL GRANULAR EN CORONA DE DIQUE | 1d | 2023-04-18 | 2023-04-18 | 163 | 27d |  |

| ID | WBS | Task | Duration | Start | Finish | Predecessors | Total slack | Free slack |
| --- | --- | --- | --- | --- | --- | --- | --- | --- |
| 165 | 1.3.7 | **MUROS DE CONCRETO ARMADO SOBRE CANAL HUACA NEPEÑA** | 49d | 2023-03-05 | 2023-04-22 |  | 23d |  |
| 166 | 1.3.7.1 | **MOVIMIENTO DE TIERRAS** | 49d | 2023-03-05 | 2023-04-22 |  | 21d |  |
| 167 | 1.3.7.1.1 | EXCAVACIÓN ESTRUCTURAL PARA OBRAS DE ARTE | 9d | 2023-03-05 | 2023-03-13 | 94 | 43d | 0d |
| 168 | 1.3.7.1.2 | RELLENO ESTRUCTURAL PARA OBRAS DE ARTE CON MATERIAL PROPIO | 4d | 2023-04-19 | 2023-04-22 | 164 | 21d | 0d |
| 169 | 1.3.7.2 | **OBRAS DE CONCRETO** | 14d | 2023-03-14 | 2023-03-27 |  | 43d |  |
| 170 | 1.3.7.2.1 | CONCRETO F'C=100 Kg/cm2 | 1d | 2023-03-14 | 2023-03-14 | 167 | 43d | 0d |
| 171 | 1.3.7.2.2 | CONCRETO F'C=280 Kg/cm2 | 5d | 2023-03-23 | 2023-03-27 | 172FS-3d | 49d |  |
| 172 | 1.3.7.2.3 | ENCOFRADO Y DESENCOFRADO | 11d | 2023-03-15 | 2023-03-25 | 170 | 43d | 0d |
| 173 | 1.3.7.2.4 | ACERO DE REFUERZO Fy=4200 Kg/cm2 | 11d | 2023-03-15 | 2023-03-25 | 172SS | 51d |  |
| 174 | 1.3.7.2.5 | SUMINISTRO E INSTALACIÓN DE TEKNOPORT e=3/4" | 9d | 2023-03-17 | 2023-03-25 | 172SS+2d | 51d | 0d |
| 175 | 1.3.7.2.6 | JUNTA con sellante expandible 1" x 3/4" | 9d | 2023-03-17 | 2023-03-25 | 174SS | 51d |  |
| 176 | 1.3.8 | **RETORNO EVACUADOR TOMA 4A** | 42d | 2023-03-14 | 2023-04-24 |  | 21d |  |
| 177 | 1.3.8.1 | **MOVIMIENTO DE TIERRAS** | 42d | 2023-03-14 | 2023-04-24 |  | 21d |  |
| 178 | 1.3.8.1.1 | EXCAVACIÓN ESTRUCTURAL PARA OBRAS DE ARTE | 7d | 2023-03-14 | 2023-03-20 | 167 | 50d | 0d |
| 179 | 1.3.8.1.2 | CAMA DE ARENA | 1d | 2023-03-21 | 2023-03-21 | 178 | 50d | 0d |
| 180 | 1.3.8.1.3 | RELLENO ESTRUCTURAL PARA OBRAS DE ARTE CON MATERIAL PROPIO | 2d | 2023-04-23 | 2023-04-24 | 168 | 21d |  |
| 181 | 1.3.8.2 | **OBRAS DE CONCRETO** | 8d | 2023-03-26 | 2023-04-02 |  | 43d |  |
| 182 | 1.3.8.2.1 | CONCRETO F'C=100 Kg/cm2 | 2d | 2023-03-26 | 2023-03-27 | 172 | 43d | 0d |
| 183 | 1.3.8.2.2 | CONCRETO F'C=280 Kg/cm2 | 1d | 2023-04-02 | 2023-04-02 | 189 | 43d |  |
| 184 | 1.3.8.2.3 | ENCOFRADO Y DESENCOFRADO | 4d | 2023-03-28 | 2023-03-31 | 182 | 43d | 0d |
| 185 | 1.3.8.2.4 | ACERO DE REFUERZO Fy=4200 Kg/cm2 | 4d | 2023-03-28 | 2023-03-31 | 184SS | 45d |  |
| 186 | 1.3.8.3 | **TUBERÍAS** | 5d | 2023-03-22 | 2023-03-26 |  | 50d |  |
| 187 | 1.3.8.3.1 | SUMINISTRO E INSTALACIÓN DE TUBERÍA HDPE DN600 mm | 5d | 2023-03-22 | 2023-03-26 | 179 | 50d |  |
| 188 | 1.3.8.4 | **COMPUERTAS Y VÁLVULAS** | 2d | 2023-03-31 | 2023-04-01 |  | 43d |  |
| 189 | 1.3.8.4.1 | COMPUERTA DE CHARNELA DN600 mm | 2d | 2023-03-31 | 2023-04-01 | 184FS-1d | 43d | 0d |

| ID | WBS | Task | Duration | Start | Finish | Predecessors | Total slack |
| --- | --- | --- | --- | --- | --- | --- | --- |
| 190 | 1.3.9 | **TRANSPORTE DE MATERIAL** | 138d | 2022-12-29 | 2023-05-15 |  | 0d |
| 191 | 1.3.9.1 | TRANSPORTE DE MATERIAL GRANULAR PARA DISTANCIAS <1KM | 93d | 2023-02-12 | 2023-05-15 | 115SS | 0d |
| 192 | 1.3.9.2 | TRANSPORTE DE ROCA PARA DISTANCIAS <1KM | 123d | 2023-01-13 | 2023-05-15 | 118SS | 0d |
| 193 | 1.3.9.3 | TRANSPORTE DE ROCA PARA DISTANCIAS >1KM | 123d | 2023-01-13 | 2023-05-15 | 192SS | 0d |
| 194 | 1.3.9.4 | TRANSPORTE DE MATERIAL EXCEDENTE PARA DISTANCIAS <1KM | 138d | 2022-12-29 | 2023-05-15 | 87SS | 0d |
| 195 | 1.3.9.5 | TRANSPORTE DE MATERIAL EXCEDENTE PARA DISTANCIAS >1KM | 138d | 2022-12-29 | 2023-05-15 | 194SS | 0d |
| 196 | 1.3.10 | **PROGRAMA DE CIERRE DE OBRA** | 138d | 2022-12-29 | 2023-05-15 |  | 0d |
| 197 | 1.3.10.1 | ACONDICIONAMIENTO DE DEPOSITOS DE MATERIALES EXCEDENTES (DME) | 138d | 2022-12-29 | 2023-05-15 | 194SS | 0d |
| 198 | 1.3.10.2 | RESTAURACIÓN DE ÁREAS DE INSTALACIONES PROVISIONALES | 5d | 2023-05-11 | 2023-05-15 | 66FS-5d | 0d |
| 199 | 1.3.11 | **SEGURIDAD Y SALUD OCUPACIONAL** | 145d | 2022-12-22 | 2023-05-15 |  | 0d |
| 200 | 1.3.11.1 | SEGURIDAD Y SALUD OCUPACIONAL | 145d | 2022-12-22 | 2023-05-15 | 69SS+4d | 0d |
| 201 | 1.3.11.2 | IMPLEMENTACIÓN DEL PLAN PARA LA VIGILANCIA, PREVENCIÓN Y CONTROL DE COVID-19 EN EL TRABAJO | 145d | 2022-12-22 | 2023-05-15 | 200SS | 0d |
